# Gantt Construccion pREFABRICADA

Schedule from MS Project, 2011-08-26 to 2012-01-25.

## Calendars

- Estándar: Mon-Fri 09:00-13:00, 15:00-19:00; Sat-Sun off.

## Schedule

| ID | Task | Type | Duration | Start | Finish | Predecessors | Total slack |
| --- | --- | --- | --- | --- | --- | --- | --- |
| 1 | A. del Terreno |  | 7d | 2011-08-26 | 2011-09-05 |  | 0d |
| 2 | Saneamiento |  | 6d | 2011-09-06 | 2011-09-13 | 1 | 0d |
| 3 | Cimentaciones |  | 15d | 2011-09-14 | 2011-10-04 | 2 | 0d |
| 4 | Estrucctura |  | 10d | 2011-10-05 | 2011-10-18 | 3 | 0d |
| 5 | Cerram. Y Partic. |  | 12d | 2011-10-19 | 2011-11-03 | 4 | 0d |
| 6 | Cubierta |  | 5d | 2011-10-19 | 2011-10-25 | 4 | 7d |
| 7 | Revestimientos |  | 35d | 2011-11-18 | 2012-01-05 | 9 | 0d |
| 8 | Carpintería |  | 14d | 2012-01-06 | 2012-01-25 | 7 | 0d |
| 9 | Instalaciones |  | 10d | 2011-11-04 | 2011-11-17 | 5, 6 | 0d |
| 10 | Varios |  | 8d | 2012-01-06 | 2012-01-17 | 7 | 6d |
| 11 | fin | milestone | 0d | 2012-01-25 | 2012-01-25 | 8, 10 | 0d |
